# Proyecto de Ejemplo 1

Schedule from MS Project, 2025-01-07 to 2025-10-03, 6 hours a day.

## Calendars

- Calendario L-Mi-V: Mon 08:00-12:00, 13:00-15:00; Tue off; Wed 08:00-12:00, 13:00-15:00; Thu off; Fri 08:00-12:00, 13:00-15:00; Sat-Sun off. Exceptions (off unless hours are given): 2025-01-21 (Virgen De La Altagracia), 2025-02-27 (Independencia Nacional), 2025-04-17 (Jueves Santos), 2025-04-18 (Viernes santos), 2025-05-01 (Dia Del Trabajador), 2025-06-19 (Corpus Christi), 2025-09-24 (Dia de La Mercedes).
- Calendario Ma y J: Mon off; Tue 08:00-12:00, 13:00-15:00; Wed off; Thu 08:00-12:00, 13:00-15:00; Fri-Sun off. Exceptions (off unless hours are given): 2025-01-21 (Virgen De La Altagracia), 2025-02-27 (Independencia Nacional), 2025-04-17 (Jueves Santos), 2025-04-18 (Viernes Santos), 2025-05-01 (Dia Del Trabajador), 2025-06-19 (Corpus Christi), 2025-08-16 (Dia de la Restauracion), 2025-09-24 (Dia de Las Mercedes).
- Estándar con día feriados: Mon-Fri 09:00-13:00, 15:00-19:00; Sat-Sun off. Exceptions (off unless hours are given): 2025-01-21 (Virgen de la Altagracia), 2025-02-27 (Independencia Nacional), 2025-04-17 (Jueves Santos), 2025-04-18 (Viernes Santos), 2025-05-01 (Dia del Trabajador), 2025-06-19 (Corpus Christi), 2025-09-24 (Dia de Las Mercedes).

## Resources

| Resource |
| --- |
| Hoyero 1 |
| Hoyero 2 |
| Hoyero 3 |
| Hoyero 4 |
| Hoyero 5 |
| Hoyero 6 |
| Hoyero 7 |
| Hoyero 8 |
| Hoyero 9 |
| Hoyero 10 |
| Grúa 1 |
| Grúa 2 |
| Grúa 3 |
| Grúa 4 |
| Grúa 5 |
| Canasto 1 |
| Canasto 2 |
| Canasto 3 |
| Canasto 4 |
| Canasto 5 |
| Canasto 6 |
| Canasto 7 |
| Canasto 8 |
| Canasto 9 |
| Canasto 10 |
| Brigada de Normalización 1 |
| Brigada de Normalización 2 |
| Brigada de Normalización 3 |
| Brigada de Normalización 4 |
| Brigada de Normalización 5 |
| Supervisor 1 |
| Supervisor 2 |
| Supervisor 3 |
| Supervisor 4 |
| Supervisor 5 |
| Supervisor 6 |
| Supervisor 7 |
| Supervisor 8 |
| Supervisor 9 |
| Supervisor 10 |
| Capataz 1 |
| Capataz 2 |
| Capataz 3 |
| Capataz 4 |
| Capataz 5 |
| Capataz 6 |
| Capataz 7 |
| Capataz 8 |
| Capataz 9 |
| Capataz 10 |
| Brigada de Poda 1 |
| Brigada de Poda 2 |
| Brigada de Poda 3 |
| Brigada de Poda 4 |
| Brigada de Poda 5 |
| Brigada de Poda 6 |
| Brigada de Poda 7 |
| Brigada de Poda 8 |
| Brigada de Poda 9 |
| Brigada de Poda 10 |
| Brigada Ligera 1 |
| Brigada Ligera 2 |
| Brigada Ligera 3 |
| Brigada Ligera 4 |
| Brigada Ligera 5 |
| Brigada Ligera 6 |
| Brigada Ligera 7 |
| Brigada Ligera 8 |
| Brigada Ligera 9 |
| Brigada Ligera 10 |
| Hoyero 1 A |
| Hoyero 2 B |
| Hoyero 3 C |
| Hoyero 4 D |
| Hoyero 5 E |
| Hoyero 6 F |
| Hoyero 7 G |
| Hoyero 8 H |
| Hoyero 9 I |
| Hoyero 10 J |
| Grúa 1 A |
| Grúa 2 B |
| Grúa 3 C |
| Grúa 4 D |
| Grúa 5 E |
| Canasto 1 A |
| Canasto 2 B |
| Canasto 3 C |
| Canasto 4 D |
| Canasto 5 E |
| Canasto 6 F |
| Canasto 7 G |
| Canasto 8 H |
| Canasto 9 I |
| Canasto 10 J |
| Brigada de Normalización 1 A |
| Brigada de Normalización 2 B |
| Brigada de Normalización 3 C |
| Brigada de Normalización 4 D |
| Brigada de Normalización 5 E |
| Brigada de Normalización 6 F |
| Brigada de Normalización 7 G |
| Brigada de Normalización 8 H |
| Brigada de Normalización 9 I |
| Brigada de Normalización 10 J |
| Supervisor 1 A |
| Supervisor 2 B |
| Supervisor 3 C |
| Supervisor 4 D |
| Supervisor 5 E |
| Supervisor 6 F |
| Supervisor 7 G |
| Supervisor 8 H |
| Supervisor 9 I |
| Supervisor 10 J |
| Capataz 1 A |
| Capataz 2 B |
| Capataz 3 C |
| Capataz 4 D |
| Capataz 5 E |
| Capataz 6 F |
| Capataz 7 G |
| Capataz 8 H |
| Capataz 9 I |
| Capataz 10 J |
| Brigada de Poda 1 A |
| Brigada de Poda 2 B |
| Brigada de Poda 3 C |
| Brigada de Poda 4 D |
| Brigada de Poda 5 E |
| Brigada de Poda 6 F |
| Brigada de Poda 7 G |
| Brigada de Poda 8 H |
| Brigada de Poda 9 I |
| Brigada de Poda 10 J |
| Brigada Ligera 1 A |
| Brigada Ligera 2 B |
| Brigada Ligera 3 C |
| Brigada Ligera 4 D |
| Brigada Ligera 5 E |
| Brigada Ligera 6 F |
| Brigada Ligera 7 G |
| Brigada Ligera 8 H |
| Brigada Ligera 9 I |
| Brigada Ligera 10 J |
| Hoyero 11 |
| Hoyero 12 |
| Hoyero 13 |
| Hoyero 14 |
| Hoyero 15 |
| Hoyero 11 K |
| Hoyero 12 L |
| Hoyero 13 M |
| Hoyero 14 N |
| Hoyero 15 Ñ |

## Schedule

| ID | WBS | Task | Duration | Start | Finish | Predecessors | Total slack | Free slack | Constraint | Calendar | Resources | Work | Días Calendario | Cantidad |
| --- | --- | --- | --- | --- | --- | --- | --- | --- | --- | --- | --- | --- | --- | --- |
| 1 | 1 | **Cronograma LOTE 8 SANC105 (AGUA BUENA)** | 248.67d | 2025-01-07 | 2025-10-03 |  | 0d |  |  | Estándar con día feriados |  | 6462h | 270días |  |
| 2 | 1.1 | **Poligono 1** | 56d | 2025-01-08 | 2025-05-19 |  | 0d |  |  |  |  | 1590h | 132días |  |
| 3 | 1.1.1 | Excavaciones | 5d | 2025-01-08 | 2025-01-17 |  | 0d |  | start no earlier than 2025-01-08 |  | Hoyero 3; Hoyero 4; Hoyero 5; Hoyero 6; Hoyero 7; Hoyero 8; Hoyero 9; Hoyero 10; Hoyero 1; Hoyero 2 | 300h | 10días | 185 |
| 4 | 1.1.2 | Izado de postes | 5d | 2025-01-08 | 2025-01-17 | 3SS | 0d |  |  |  | Grúa 3; Grúa 1; Grúa 2 | 90h | 10días | 98 |
| 5 | 1.1.3 | Cimentaciones | 1d | 2025-01-17 | 2025-01-17 | 4FF | 130d |  |  |  | Brigada Ligera 1; Brigada Ligera 2 | 12h | 1días |  |
| 6 | 1.1.4 | Retenidas | 4d | 2025-01-13 | 2025-01-20 | 4SS+2d | 0d |  |  |  | Brigada Ligera 3; Canasto 1; Brigada Ligera 4 | 72h | 8días | 87 |
| 7 | 1.1.5 | Armados MT y BT | 14d | 2025-01-22 | 2025-02-21 | 6 | 0d |  |  |  | Canasto 3; Canasto 4; Canasto 5; Canasto 2 | 336h | 31días | 459 |
| 8 | 1.1.6 | Tendido de Conductor MT y BT | 7d | 2025-02-24 | 2025-03-10 | 7 | 0d |  |  |  | Canasto 3; Canasto 2; Canasto 4; Canasto 5 | 168h | 15días | 10,038 |
| 9 | 1.1.7 | Puesta a Tierra | 2d | 2025-03-12 | 2025-03-14 | 8 | 0d |  |  |  | Canasto 5; Canasto 4; Canasto 1; Canasto 2; Canasto 3 | 60h | 3días | 107 |
| 10 | 1.1.8 | Conexiones y Jumper | 3d | 2025-03-17 | 2025-03-21 | 9 | 0d |  |  |  | Canasto 1; Canasto 2; Canasto 3; Canasto 4; Canasto 5 | 90h | 5días | 132 |
| 11 | 1.1.9 | Transformadores | 1d | 2025-03-24 | 2025-03-24 | 10 | 0d |  |  |  | Grúa 1; Canasto 1; Canasto 2; Canasto 3; Grúa 2; Grúa 3; Canasto 4; Canasto 5; Grúa 4; Grúa 5 | 60h | 1días | 19 |
| 12 | 1.1.10 | Alumbrado Público | 2d | 2025-03-26 | 2025-03-28 | 11 | 0d |  |  |  | Canasto 2; Canasto 1; Canasto 3; Canasto 4; Canasto 5 | 60h | 3días | 141 |
| 13 | 1.1.11 | Etiquetas CT | 1d | 2025-03-31 | 2025-03-31 | 12 | 0d |  |  |  | Canasto 1; Canasto 2 | 12h | 1días | 24 |
| 14 | 1.1.12 | Totalizadores | 3d | 2025-04-02 | 2025-04-07 | 13 | 0d |  |  |  | Canasto 3; Canasto 4; Canasto 5 | 54h | 6días | 24 |
| 15 | 1.1.13 | Acometida | 18d | 2025-04-04 | 2025-05-16 | 14SS+1d | 58d | 0d |  |  | Brigada de Normalización 1; Brigada de Normalización 2 | 216h | 43días | 712 |
| 16 | 1.1.14 | Remoción | 5d | 2025-05-09 | 2025-05-19 | 15SS+14d | 58d |  |  |  | Canasto 1; Grúa 1 | 60h | 11días | 245 |
| 18 | 1.2 | **Poligono 2** | 52d | 2025-01-07 | 2025-07-22 |  | 21d |  |  | Calendario Ma y J |  | 1536h | 197días |  |
| 19 | 1.2.1 | Excavaciones | 6d | 2025-01-07 | 2025-01-28 |  | 21d | 0d | start no earlier than 2025-01-07 | Calendario Ma y J | Hoyero 3 C; Hoyero 4 D; Hoyero 5 E; Hoyero 6 F; Hoyero 7 G; Hoyero 8 H; Hoyero 9 I; Hoyero 10 J; Hoyero 1 A; Hoyero 2 B | 360h | 22días | 248 |
| 20 | 1.2.2 | Izado de postes | 6d | 2025-01-07 | 2025-01-28 | 19SS | 21d | 0d |  | Calendario Ma y J | Grúa 3 C; Grúa 1 A; Grúa 2 B | 108h | 22días | 131 |
| 21 | 1.2.3 | Cimentaciones | 2d | 2025-01-28 | 2025-01-30 | 20FF+1d | 21d | 0d |  | Calendario Ma y J | Brigada Ligera 1 A; Brigada Ligera 2 B; Brigada Ligera 3 C; Brigada Ligera 4 D; Brigada Ligera 5 E | 60h | 3días | 57 |
| 22 | 1.2.4 | Retenidas | 2d | 2025-02-04 | 2025-02-06 | 21 | 21d | 0d |  | Calendario Ma y J | Brigada Ligera 2 B; Brigada Ligera 3 C; Canasto 1 A; Brigada Ligera 4 D; Brigada Ligera 5 E; Brigada Ligera 1 A | 72h | 3días | 117 |
| 23 | 1.2.5 | Armados MT y BT | 5d | 2025-02-11 | 2025-02-25 | 22 | 21d | 0d |  | Calendario Ma y J | Canasto 3 C; Canasto 4 D; Canasto 5 E; Canasto 2 B; Canasto 1 A | 150h | 15días | 218 |
| 24 | 1.2.6 | Tendido de Conductor MT y BT | 7d | 2025-03-04 | 2025-03-25 | 23 | 21d | 0d |  | Calendario Ma y J | Canasto 3 C; Canasto 4 D; Canasto 5 E; Canasto 1 A; Canasto 2 B | 210h | 22días | 11,539 |
| 25 | 1.2.7 | Puesta a Tierra | 2d | 2025-03-27 | 2025-04-01 | 24 | 21d | 0d |  | Calendario Ma y J | Canasto 2 B; Canasto 3 C; Canasto 1 A; Canasto 4 D; Canasto 5 E | 60h | 6días | 107 |
| 26 | 1.2.8 | Conexiones y Jumper | 2d | 2025-04-03 | 2025-04-08 | 25 | 21d | 0d |  | Calendario Ma y J | Canasto 5 E; Canasto 4 D; Canasto 1 A; Canasto 2 B; Canasto 3 C | 60h | 6días | 100 |
| 27 | 1.2.9 | Transformadores | 1d | 2025-04-10 | 2025-04-10 | 26 | 21d | 0d |  | Calendario Ma y J | Grúa 2 B; Grúa 3 C; Canasto 1 A; Canasto 2 B; Canasto 3 C; Grúa 1 A; Grúa 4 D; Grúa 5 E; Canasto 4 D; Canasto 5 E | 60h | 1días | 18 |
| 28 | 1.2.10 | Alumbrado Público | 2d | 2025-04-15 | 2025-04-22 | 27 | 21d | 0d |  | Calendario Ma y J | Canasto 5 E; Canasto 4 D; Canasto 1 A; Canasto 2 B; Canasto 3 C | 60h | 8días | 146 |
| 29 | 1.2.11 | Etiquetas CT | 1d | 2025-04-24 | 2025-04-24 | 28 | 44d |  |  | Calendario Ma y J | Canasto 2 B; Canasto 1 A | 12h | 1días | 21 |
| 30 | 1.2.12 | Totalizadores | 2d | 2025-04-24 | 2025-04-29 | 28 | 21d | 0d |  | Calendario Ma y J | Canasto 3 C; Canasto 4 D; Canasto 5 E | 36h | 6días | 21 |
| 31 | 1.2.13 | Acometida | 17d | 2025-04-29 | 2025-07-01 | 30SS+1d | 21d | 0d |  | Calendario Ma y J | Brigada de Normalización 1 A; Brigada de Normalización 2 B | 204h | 64días | 671 |
| 32 | 1.2.14 | Remoción | 7d | 2025-07-01 | 2025-07-22 | 31SS+16d | 21d |  |  | Calendario Ma y J | Canasto 1 A; Grúa 1 A | 84h | 22días | 328 |

Notes:
- 4: No se le asigna canasto, pero requiere uno para apertura y cierre de seccionador
- 20: No se le asigna canasto, pero requiere uno para apertura y cierre de seccionador

| ID | WBS | Task | Duration | Start | Finish | Predecessors | Total slack | Free slack | Resources | Work | Días Calendario | Cantidad |
| --- | --- | --- | --- | --- | --- | --- | --- | --- | --- | --- | --- | --- |
| 34 | 1.3 | **Poligono 3** | 108d | 2025-01-22 | 2025-10-03 |  | 0d |  |  | 3336h | 255días |  |
| 35 | 1.3.1 | Excavaciones | 14d | 2025-01-22 | 2025-02-21 | 3FS+1d | 92d | 0d | Hoyero 5; Hoyero 6; Hoyero 7; Hoyero 8; Hoyero 9; Hoyero 10; Hoyero 1; Hoyero 2; Hoyero 3; Hoyero 4 | 840h | 31días | 554 |
| 36 | 1.3.2 | Izado de postes | 14d | 2025-01-22 | 2025-02-21 | 35SS | 92d | 0d | Grúa 2; Grúa 3; Grúa 1 | 252h | 31días | 286 |
| 37 | 1.3.3 | Cimentaciones | 2d | 2025-02-19 | 2025-02-21 | 36FF | 94d |  | Brigada Ligera 1; Brigada Ligera 2 | 24h | 3días | 23 |
| 38 | 1.3.4 | Retenidas | 9d | 2025-02-07 | 2025-02-26 | 36SS+7d, 37 | 92d |  | Brigada Ligera 3; Brigada Ligera 4; Brigada Ligera 5; Canasto 1 | 216h | 20días | 268 |
| 39 | 1.3.5 | Armados MT y BT | 21d | 2025-04-09 | 2025-05-28 | 14 | 0d |  | Canasto 2; Canasto 3; Canasto 4; Canasto 5 | 504h | 50días | 661 |
| 40 | 1.3.6 | Tendido de Conductor MT y BT | 15d | 2025-05-30 | 2025-07-02 | 39 | 0d |  | Canasto 2; Canasto 3; Canasto 4; Canasto 5; Canasto 1 | 450h | 34días | 25,679 |
| 41 | 1.3.7 | Puesta a Tierra | 4d | 2025-07-04 | 2025-07-11 | 40 | 0d |  | Canasto 3; Canasto 4; Canasto 5; Canasto 2; Canasto 1 | 120h | 8días | 216 |
| 42 | 1.3.8 | Conexiones y Jumper | 5d | 2025-07-14 | 2025-07-23 | 41 | 0d |  | Canasto 3; Canasto 4; Canasto 5; Canasto 1; Canasto 2 | 150h | 10días | 262 |
| 43 | 1.3.9 | Transformadores | 3d | 2025-07-25 | 2025-07-30 | 42 | 0d |  | Canasto 4; Canasto 5; Grúa 4; Grúa 5; Grúa 3; Canasto 3; Canasto 1; Canasto 2; Grúa 2; Grúa 1 | 180h | 6días | 43 |
| 44 | 1.3.10 | Alumbrado Público | 4d | 2025-08-01 | 2025-08-08 | 43 | 0d |  | Canasto 4; Canasto 1; Canasto 2; Canasto 3; Canasto 5 | 120h | 8días | 334 |
| 45 | 1.3.11 | Etiquetas CT | 1d | 2025-08-11 | 2025-08-11 | 44 | 0d |  | Canasto 1; Canasto 2; Canasto 3 | 18h | 1días | 50 |
| 46 | 1.3.12 | Totalizadores | 3d | 2025-08-13 | 2025-08-18 | 45 | 0d |  | Canasto 4; Canasto 5; Canasto 3; Canasto 1; Canasto 2 | 90h | 6días | 50 |
| 47 | 1.3.13 | Acometida | 17d | 2025-08-15 | 2025-09-22 | 46SS+1d | 0d |  | Brigada de Normalización 1; Brigada de Normalización 2 | 204h | 39días | 687 |
| 48 | 1.3.14 | Remoción | 14d | 2025-09-01 | 2025-10-03 | 47SS+7d | 0d |  | Canasto 1; Grúa 1 | 168h | 33días | 716 |

Notes:
- 36: No se le asigna canasto, pero requiere uno para apertura y cierre de seccionador
